# GAI02_CONT_R047_proyecto_con_recursos_asignados

Schedule from MS Project, 2012-01-02 to 2012-03-26, costs in €.
CONTRERAS FAMILY

## Calendars

- Estándar: Mon-Fri 09:00-13:00, 15:00-19:00; Sat-Sun off. Exceptions (off unless hours are given): 2012-02-16 (Día de las Fuerzas Desarmadas), 2012-03-15 (Día de los Gestores de Proyecto Agobiados).

## Resources

| Resource | Cost per use |
| --- | --- |
| García Salado Proyectos | 8400 |
| Reformas Otilio, S.L. | 72500 |
| Departamento de Informática |  |
| Gaudí Decoradores, S.A. | 4500 |
| Alejandro |  |
| Rigoberto Pintores | 9200 |
| Gaudí Decoradores, S.A. (mobiliario) | 43000 |
| Material eléctrico instalación informática | 1680 |
| Equipos informáticos clientes | 12000 |
| Impresoras y escáneres | 2140 |
| Servidores | 3000 |
| Rack y switches | 1750 |
| Jiménez Oneroso, Santos (proyecto eléctrico) | 1400 |
| Licencias software | 4210 |
| Licencia Ayuntamiento | 4120 |

## Schedule

| ID | WBS | Task | Type | Duration | Start | Finish | Predecessors | Total slack | Resources | Work | Cost |
| --- | --- | --- | --- | --- | --- | --- | --- | --- | --- | --- | --- |
| 1 | 1 | **Adquisición y ampliación de oficinas** |  | 59d | 2012-01-02 | 2012-03-26 |  | 0d |  | 472h | 167,900.01 |
| 2 | 1.1 | Comienzo | milestone | 0d | 2012-01-02 | 2012-01-02 |  | 59d |  |  |  |
| 3 | 1.2 | **Diseñar reforma y decoración** |  | 25d | 2012-01-02 | 2012-02-03 |  | 0d |  | 280h | 12,900 |
| 4 | 1.2.1 | Elaborar diseño mobiliario y decoración |  | 10d | 2012-01-02 | 2012-01-13 |  | 15d | Gaudí Decoradores, S.A. | 80h | 4,500 |
| 5 | 1.2.2 | Elaborar proyecto de reforma constructiva |  | 25d | 2012-01-02 | 2012-02-03 |  | 0d | García Salado Proyectos | 200h | 8,400 |
| 6 | 1.3 | **Realizar trámites técnicos y legales** |  | 20d | 2012-02-06 | 2012-03-05 | 5 | 14d |  |  | 5,520 |
| 7 | 1.3.1 | Obtener proyecto eléctrico |  | 20d | 2012-02-06 | 2012-03-05 |  | 14d | Jiménez Oneroso, Santos (proyecto eléctrico) |  | 1,400 |
| 8 | 1.3.2 | Obtener licencia Ayuntamiento |  | 14d | 2012-02-06 | 2012-02-24 |  | 20d | Licencia Ayuntamiento |  | 4,120 |
| 9 | 1.4 | **Conseguir presupuestos** |  | 7d | 2012-02-06 | 2012-02-14 | 3 | 0d |  |  |  |
| 10 | 1.4.1 | Obtener presupuesto reforma constructiva |  | 7d | 2012-02-06 | 2012-02-14 |  | 0d |  |  |  |
| 11 | 1.4.2 | Obtener presupuesto mobiliario y decoración |  | 7d | 2012-02-06 | 2012-02-14 |  | 0d |  |  |  |
| 12 | 1.5 | Reunión análisis proyectos y presupuestos | milestone | 0d | 2012-02-14 | 2012-02-14 | 9 | 0d |  |  |  |
| 13 | 1.6 | **Realizar reforma constructiva (empresa externa)** |  | 9d | 2012-02-15 | 2012-02-28 | 12 | 0d | Reformas Otilio, S.L. | 72h | 72,500.01 |
| 14 | 1.6.1 | Demolición tabiquería interna |  | 1d | 2012-02-15 | 2012-02-15 |  | 0d |  |  |  |
| 15 | 1.6.2 | Instalación tabiquería de pladur |  | 5d | 2012-02-17 | 2012-02-23 | 14 | 0d |  |  |  |
| 16 | 1.6.3 | Instalación fontanería |  | 2d | 2012-02-24 | 2012-02-27 | 15 | 1d |  |  |  |
| 17 | 1.6.4 | Adaptación ventanas |  | 3d | 2012-02-24 | 2012-02-28 | 15 | 0d |  |  |  |
| 18 | 1.6.5 | Colocación puertas |  | 2d | 2012-02-24 | 2012-02-27 | 15 | 1d |  |  |  |
| 19 | 1.6.6 | Instalación sistema antiincendios |  | 2d | 2012-02-24 | 2012-02-27 | 15 | 1d |  |  |  |
| 20 | 1.7 | Presentación informe consejo de administración | milestone | 0d | 2012-02-28 | 2012-02-28 | 13 | 18d |  |  |  |
| 21 | 1.8 | **Instalación informática** |  | 12d | 2012-02-29 | 2012-03-16 | 13 | 0d | Departamento de Informática | 96h | 24,780 |
| 22 | 1.8.1 | Diseñar la red |  | 5d | 2012-02-29 | 2012-03-06 |  | 0d |  |  |  |
| 23 | 1.8.2 | **Comprar equipos y materiales** |  | 5d | 2012-03-07 | 2012-03-13 | 22 | 0d |  |  | 18,820 |
| 24 | 1.8.2.1 | Comprar cables y material eléctrico |  | 2d | 2012-03-07 | 2012-03-08 |  | 3d | Material eléctrico instalación informática |  | 1,680 |
| 25 | 1.8.2.2 | Comprar servidores y equipos clientes |  | 5d | 2012-03-07 | 2012-03-13 |  | 0d | Equipos informáticos clientes; Servidores |  | 15,000 |
| 26 | 1.8.2.3 | Comprar impresoras y escáneres |  | 5d | 2012-03-07 | 2012-03-13 |  | 0d | Impresoras y escáneres |  | 2,140 |

| ID | WBS | Task | Type | Duration | Start | Finish | Predecessors | Total slack | Deadline | Resources | Work | Cost |
| --- | --- | --- | --- | --- | --- | --- | --- | --- | --- | --- | --- | --- |
| 27 | 1.8.3 | **Instalar el cableado, switches y armario principal** |  | 3d | 2012-02-29 | 2012-03-02 |  | 9d |  |  |  | 1,750 |
| 28 | 1.8.3.1 | Instalación de switches y configuración |  | 2d | 2012-02-29 | 2012-03-01 |  | 10d |  | Rack y switches |  | 1,750 |
| 29 | 1.8.3.2 | Instalar armario principal y rack |  | 2d | 2012-02-29 | 2012-03-01 |  | 10d |  |  |  |  |
| 30 | 1.8.3.3 | Tirar el cableado |  | 3d | 2012-02-29 | 2012-03-02 |  | 9d |  |  |  |  |
| 31 | 1.8.4 | **Instalar software en equipos** |  | 2d | 2012-03-14 | 2012-03-16 | 23 | 0d |  |  |  | 4,210 |
| 32 | 1.8.4.1 | Instalar programas ofimáticos |  | 2d | 2012-03-14 | 2012-03-16 |  | 0d |  | Licencias software |  | 4,210 |
| 33 | 1.8.4.2 | Configurar la red |  | 2d | 2012-03-14 | 2012-03-16 |  | 0d |  |  |  |  |
| 34 | 1.8.4.3 | Instalar sistemas operativos |  | 2d | 2012-03-14 | 2012-03-16 |  | 0d |  |  |  |  |
| 35 | 1.8.5 | Instalar impresoras y escáneres |  | 1d | 2012-02-29 | 2012-02-29 |  | 11d |  |  |  |  |
| 36 | 1.9 | Presentación certificados final de obra | milestone | 0d | 2012-03-13 | 2012-03-13 | 23 | 1d | 2012-03-14 |  |  |  |
| 37 | 1.10 | **Adquirir mobiliario y decorar** |  | 6d | 2012-03-19 | 2012-03-26 | 21 | 0d |  |  | 24h | 52,200 |
| 38 | 1.10.1 | Pintar dependencias |  | 3d | 2012-03-19 | 2012-03-21 |  | 0d |  | Rigoberto Pintores | 24h | 9,200 |
| 39 | 1.10.2 | Colocar mobiliario y decoración |  | 3d | 2012-03-22 | 2012-03-26 | 38 | 0d |  | Gaudí Decoradores, S.A. (mobiliario) |  | 43,000 |
| 40 | 1.11 | Fin de proyecto | milestone | 0d | 2012-03-26 | 2012-03-26 | 37 | 0d |  |  |  |  |
